# CONTRATACIÓN DE OPERADOR DE CANTERAS DE ROCA - RÍO CHICAMA

How a schedule from Primavera P6 changed from version to version. A marks actual dates.

## Version 1 (data date 2023-02-06, saved 2023-01-12, file OHLA-B7_Cantera Chicama.xer)

| ID | WBS | Task | Duration | Start | Finish | Predecessors | Total float |
| --- | --- | --- | --- | --- | --- | --- | --- |
|  | 1 | **HITOS** |  | 2023-02-06 | 2024-10-13 |  |  |
| A1000 |  | Adjudicación | 0d | 2023-02-06 | 2023-02-06 |  | 0d |
| A1010 |  | Suscripción de Subcontrato | 0d | 2023-02-16 | 2023-02-16 | A1000 FS+9d | 0d |
| A1020 |  | Inicio de Servicio - Acceso al Sitio | 0d | 2023-03-01 | 2023-03-01 | A1010 FS+11d | 0d |
| A1030 |  | Autorización para adquisición y almacenamiento de explosivos | 0d | 2023-03-08 | 2023-03-08 | A1070, A1080, A1090, A1100 | 483d |
| A1040 |  | Primera Voladura | 0d | 2023-04-01 | 2023-04-01 | A1030, A1010 FS+38d, A1280 SS+13d, A1410 SS+6d | 462d |
| A1050 |  | Entrega de 800,000 m3 de roca seleccionada | 0d | 2024-01-21 | 2024-01-21 | A1420 SF+236d | 220d |
| A1060 |  | Culminación del Servicio | 0d | 2024-10-13 | 2024-10-13 | A1120, A1040, A1050, A1150 | 0d |
|  | 2 | **OBRAS PROVISIONALES** |  | 2023-02-16 | 2023-03-08 |  |  |
| A1070 |  | Tramite, Gestión y Obtención de permisos para uso y adquisición de explosivos | 17d | 2023-02-16 | 2023-03-08 | A1010 | 0d |
| A1080 |  | Tramite, Gestión y Obtención de permisos para manipulación de explosivos | 17d | 2023-02-16 | 2023-03-08 | A1010 | 0d |
| A1090 |  | Tramite, Gestión y Obtención de permisos para almacenamiento y uso de Polvorín | 17d | 2023-02-16 | 2023-03-08 | A1010 | 0d |
| A1100 |  | Tramite, Gestión y Obtención de permisos para Explotación de Canteras | 17d | 2023-02-16 | 2023-03-08 | A1010 | 0d |
|  | 3 | **OBRAS PRELIMINARES** |  | 2023-03-01 | 2024-10-13 |  |  |
|  | 1 | **Movilización y Desmovilización** |  | 2023-03-01 | 2024-10-13 |  |  |
| A1110 |  | Movilización de equipos a obra | 26d | 2023-03-01 | 2023-03-31 | A1020 | 0d |
| A1120 |  | Desmovilización de equipos de obra | 12d | 2024-09-28 | 2024-10-13 | A1420, A1430, A1460, A1200, A1220, A1230, A1260, A1350, A1360, A1370, A1540, A1560, A1590, A1600, A1330, A1480, A1490, A1520, A1440 | 0d |
|  | 2 | **Trazo y replanteo** |  | 2023-03-04 | 2024-10-12 |  |  |
| A1130 |  | Trazo y replanteo topográfico al inicio de obra | 12d | 2023-03-04 | 2023-03-18 | A1110 SS+3d | 0d |
| A1140 |  | Control topográfico del material seleccionado | 461d | 2023-03-18 | 2024-09-27 | A1130 | 1d |
| A1150 |  | Levantamiento Topografico final de obra | 12d | 2024-09-27 | 2024-10-12 | A1140 | 1d |
|  | 3 | **Construcción y mantenimiento de accesos** |  | 2023-03-08 | 2024-09-22 |  |  |
| A1160 |  | Desbroce y Remoción de Suelo Vegetal con Equipo | 86d | 2023-03-08 | 2023-06-20 | A1130 SS+3d | 0d |
| A1170 |  | Excavación en Material Común | 86d | 2023-03-08 | 2023-06-20 | A1160 SS | 0d |
| A1180 |  | Excavación en roca fracturada | 86d | 2023-03-08 | 2023-06-20 | A1170 SS | 0d |
| A1190 |  | Excavación en roca fija con martillo hidráulico | 86d | 2023-03-11 | 2023-06-23 | A1180 SS+3d | 0d |
| A1200 |  | Relleno compactado con equipo pesado para accesos | 85d | 2023-03-15 | 2023-06-25 | A1190 SS, A1210 SS | 380d |
| A1210 |  | Proceso y selección de material propio | 85d | 2023-03-15 | 2023-06-25 | A1170 SS+6d | 380d |
| A1220 |  | Producción de material de préstamo | 85d | 2023-03-15 | 2023-06-25 | A1210 SS | 380d |
| A1230 |  | Mantenimiento de accesos (L = 2km) | 460d | 2023-03-15 | 2024-09-22 | A1180 SS+6d | 5d |
|  | 4 | **Construcción de Campamentos** |  | 2023-03-08 | 2024-09-24 |  |  |
| A1280 |  | Alquiler de Polvorín temporal | 78d | 2023-03-08 | 2023-06-10 | A1130 SS+3d, A1070, A1080, A1090, A1100 | 0d |
| A1440 |  | Construcción e Implementación de Polvorin | 78d | 2023-03-08 | 2023-06-10 | A1070, A1080, A1090, A1100 | 393d |
| A1240 |  | Conformación de terraplén para campamentos | 26d | 2023-03-11 | 2023-04-13 | A1180 SS+3d | 4d |
| A1270 |  | Desbroce y remoción de suelo vegetal con equipo | 20d | 2023-03-11 | 2023-04-04 | A1240 SS | 254d |
| A1250 |  | Construcción de campamentos | 26d | 2023-03-15 | 2023-04-16 | A1240 SS+3d | 4d |
| A1260 |  | Mantenimiento de campamento | 435d | 2023-04-17 | 2024-09-24 | A1250 | 4d |
|  | 5 | **Conformación de plataforma para zonas de acopio** |  | 2023-04-04 | 2023-11-25 |  |  |
| A1290 |  | Desbroce y remoción de suelo vegetal con equipo | 82d | 2023-04-04 | 2023-07-13 | A1270 | 254d |
| A1300 |  | Excavación en Material Común | 82d | 2023-04-04 | 2023-07-13 | A1290 SS | 254d |
| A1310 |  | Relleno compactado con equipo pesado para plataforma de acopio | 170d | 2023-04-20 | 2023-11-11 | A1300 SS+12d | 254d |
| A1320 |  | Suministro, construcción e instalación de Cerco perímetrico | 170d | 2023-05-05 | 2023-11-25 | A1310 SS+12d | 254d |
| A1330 |  | Suministro, construcción e instalación de garita de control de ingreso y salida | 170d | 2023-05-05 | 2023-11-25 | A1320 SS | 254d |
|  | 6 | **Seguridad y Medio Ambiente** |  | 2023-03-01 | 2024-09-28 |  |  |
| A1340 |  | Señalización de obra | 476d | 2023-03-01 | 2024-09-27 | A1020 | 1d |
| A1350 |  | Implementación de controles ambientales durante la construcción | 476d | 2023-03-01 | 2024-09-27 | A1340 SS | 1d |
| A1360 |  | Conformación de Material Excedente en DME y DMO | 476d | 2023-03-01 | 2024-09-27 | A1340 SS | 1d |
| A1370 |  | Restauración y revegetación de áreas intervenidas | 35d | 2024-08-17 | 2024-09-28 | A1420 FF+1d, A1430 FF+1d, A1460 FF+1d, A1550 FF+1d | 0d |
|  | 4 | **EXPLOTACIÓN DE CANTERA** |  | 2023-03-18 | 2024-09-27 |  |  |
|  | 1 | **Habilitación de Cantera** |  | 2023-03-18 | 2023-11-11 |  |  |
| A1380 |  | Desbroce y remoción de suelo vegetal con equipo | 139d | 2023-03-18 | 2023-09-05 | A1190 SS+6d | 0d |
| A1390 |  | Excavación en material común (hasta roca fracturada) | 139d | 2023-03-18 | 2023-09-05 | A1380 SS | 0d |
| A1400 |  | Excavación en roca fracturada (hasta roca macizo rocoso) | 139d | 2023-03-18 | 2023-09-05 | A1390 SS | 0d |
| A1410 |  | Perforación manual y voladura (habilitación de área de perforación para Rockdrill) | 190d | 2023-03-25 | 2023-11-11 | A1400 SS+6d, A1280 SS+15d | 0d |
|  | 2 | **Producción Material en cantera de cerro (macizo rocoso)** |  | 2023-04-11 | 2024-09-27 |  |  |
|  | 1 | **Producción - roca de 0.80 - 1.50 m** |  | 2023-04-11 | 2024-09-27 |  |  |
| A1420 |  | Nuevo Alto Perú | 441d | 2023-04-11 | 2024-09-25 | A1410 SS+12d | 0d |
| A1430 |  | San Bartolo 01 | 436d | 2023-04-18 | 2024-09-26 | A1420 SS+6d | 0d |
| A1460 |  | Oso 02 | 425d | 2023-05-03 | 2024-09-27 | A1430 SS+12d | 0d |
|  | 2 | **Fracturación - roca para gaviones de 0.15 - 0.20 m** |  | 2023-04-11 | 2024-01-30 |  |  |
| A1480 |  | Nuevo Alto Perú | 235d | 2023-04-11 | 2024-01-20 | A1420 SS | 209d |
| A1490 |  | San Bartolo 01 | 235d | 2023-04-18 | 2024-01-27 | A1430 SS | 203d |
| A1520 |  | Oso 02 | 225d | 2023-05-03 | 2024-01-30 | A1460 SS | 201d |
|  | 3 | **Carguio de Material Remanente en acopio para Eliminación** |  | 2023-04-11 | 2024-09-27 |  |  |
| A1540 |  | Carguio de Material Remanente en acopio para Eliminación | 443d | 2023-04-11 | 2024-09-27 | A1420 SS | 1d |
|  | 3 | **Producción Material en cantera de cauce (boloneria suelta)** |  | 2023-04-11 | 2024-08-21 |  |  |
| A1550 |  | Fracturación y selección de Roca con martillo hidráulico | 412d | 2023-04-11 | 2024-08-21 | A1420 SS | 31d |
| A1560 |  | Carguio de Material Remanente en acopio para Eliminación | 412d | 2023-04-11 | 2024-08-21 | A1550 SS | 32d |
|  | 4 | **Carguio de Material acopiado** |  | 2023-04-11 | 2024-09-27 |  |  |
| A1570 |  | Carguio de Material acopiado | 443d | 2023-04-11 | 2024-09-27 | A1420 SS | 1d |

| ID | WBS | Task | Duration | Start | Finish | Predecessors | Total float |
| --- | --- | --- | --- | --- | --- | --- | --- |
|  | 5 | **IMPLEMENTACION PARA CONTROL Y PESAJE DE ROCA** |  | 2023-03-18 | 2024-09-03 |  |  |
|  | 1 | **Instalación de Sistema de Pesaje** |  | 2023-03-18 | 2024-09-03 |  |  |
| A1575 |  | Obras Civiles | 26d | 2023-03-18 | 2023-04-20 | A1190 SS+6d | 22d |
| A1580 |  | Instalación de balanza, caseta y tablero de control de Pesaje | 26d | 2023-04-11 | 2023-05-12 | A1130, A1575 SS+18d | 22d |
| A1590 |  | Operación y control de Sistema de pesaje | 416d | 2023-04-18 | 2024-09-03 | A1580 SS+6d | 22d |
|  | 6 | **PRUEBAS DE CONTROL DE CALIDAD** |  | 2023-04-11 | 2024-09-27 |  |  |
| A1600 |  | Ensayos de Roca | 443d | 2023-04-11 | 2024-09-27 | A1570 SS | 1d |

## Version 2 (data date 2023-02-09, saved 2023-01-29, file OHLA-B7_Cantera_Chicama.xer)

Last finish 2024-10-13 → 2024-10-15 (+2d).

Removed: A1160 Desbroce y Remoción de Suelo Vegetal con Equipo; A1220 Producción de material de préstamo; A1280 Alquiler de Polvorín temporal; A1270 Desbroce y remoción de suelo vegetal con equipo; A1290 Desbroce y remoción de suelo vegetal con equipo; A1370 Restauración y revegetación de áreas intervenidas; A1380 Desbroce y remoción de suelo vegetal con equipo

Changed:

| ID | Task | Start | Finish | Duration | Total float | Predecessors |
| --- | --- | --- | --- | --- | --- | --- |
| 1 | **HITOS** | 2023-02-06 → 2023-02-09 (+3d) | 2024-10-13 → 2024-10-15 (+2d) |  |  |  |
| A1000 | Adjudicación | 2023-02-06 → 2023-02-09 (+3d) | 2023-02-06 → 2023-02-09 (+3d) |  |  |  |
| A1010 | Suscripción de Subcontrato | 2023-02-16 → 2023-02-20 (+4d) | 2023-02-16 → 2023-02-20 (+4d) |  |  |  |
| A1020 | Inicio de Servicio - Acceso al Sitio | 2023-03-01 → 2023-03-03 (+2d) | 2023-03-01 → 2023-03-03 (+2d) |  |  | A1010 FS+11d → A1010 FS+10d |
| A1030 | Autorización para adquisición y almacenamiento de explosivos | 2023-03-08 → 2023-03-11 (+3d) | 2023-03-08 → 2023-03-11 (+3d) |  | 483d → 481d |  |
| A1040 | Primera Voladura | 2023-04-01 → 2023-04-05 (+4d) | 2023-04-01 → 2023-04-05 (+4d) |  | 462d → 460d | A1030, A1010 FS+38d, Alquiler de Polvorín temporal SS+13d, A1410 SS+6d → A1030, A1010 FS+38d, A1280 SS+13d, A1410 SS+6d |
| A1050 | Entrega de 800,000 m3 de roca seleccionada | 2024-01-21 → 2024-01-26 (+5d) | 2024-01-21 → 2024-01-26 (+5d) |  | 220d → 217d | A1420 SF+236d → A1420 SF+237d |
| A1060 | Culminación del Servicio | 2024-10-13 → 2024-10-15 (+2d) | 2024-10-13 → 2024-10-15 (+2d) |  |  |  |
| 2 | **OBRAS PROVISIONALES** | 2023-02-16 → 2023-02-20 (+4d) | 2023-03-08 → 2023-03-11 (+3d) |  |  |  |
| A1070 | Tramite, Gestión y Obtención de permisos para uso y adquisición de explosivos | 2023-02-16 → 2023-02-20 (+4d) | 2023-03-08 → 2023-03-11 (+3d) |  |  |  |
| A1080 | Tramite, Gestión y Obtención de permisos para manipulación de explosivos | 2023-02-16 → 2023-02-20 (+4d) | 2023-03-08 → 2023-03-11 (+3d) |  |  |  |
| A1090 | Tramite, Gestión y Obtención de permisos para almacenamiento y uso de Polvorín | 2023-02-16 → 2023-02-20 (+4d) | 2023-03-08 → 2023-03-11 (+3d) |  |  |  |
| A1100 | Tramite, Gestión y Obtención de permisos para Explotación de Canteras | 2023-02-16 → 2023-02-20 (+4d) | 2023-03-08 → 2023-03-11 (+3d) |  |  |  |
| 3 | **OBRAS PRELIMINARES** | 2023-03-01 → 2023-03-03 (+2d) | 2024-10-13 → 2024-10-15 (+2d) |  |  |  |
| 1 | **Movilización y Desmovilización** | 2023-03-01 → 2023-03-03 (+2d) | 2024-10-13 → 2024-10-15 (+2d) |  |  |  |
| A1110 | Movilización de equipos a obra | 2023-03-01 → 2023-03-03 (+2d) | 2023-03-31 → 2023-04-02 (+2d) |  |  |  |
| A1120 | Desmovilización de equipos de obra | 2024-09-28 → 2024-09-30 (+2d) | 2024-10-13 → 2024-10-15 (+2d) |  |  | A1420, A1430, A1460, A1200, Producción de material de préstamo, A1230, A1260, A1350, A1360, Restauración y revegetación de áreas intervenidas, A1540, A1560, A1590, A1600, A1330, A1480, A1490, A1520, A1280 → A1420, A1430, A1460, A1200, A1230, A1260, A1350, A1360, A1540, A1560, A1590, A1600, A1330, A1480, A1490, A1520 |
| 2 | **Trazo y replanteo** | 2023-03-04 → 2023-03-07 (+3d) | 2024-10-12 → 2024-10-15 (+3d) |  |  |  |
| A1130 | Trazo y replanteo topográfico al inicio de obra | 2023-03-04 → 2023-03-07 (+3d) | 2023-03-18 → 2023-03-21 (+3d) |  |  |  |
| A1140 | Control topográfico del material seleccionado | 2023-03-18 → 2023-03-21 (+3d) | 2024-09-27 → 2024-09-29 (+2d) |  | 1d → 0d |  |
| A1150 | Levantamiento Topografico final de obra | 2024-09-27 → 2024-09-30 (+3d) | 2024-10-12 → 2024-10-15 (+3d) |  | 1d → 0d |  |
| 3 | **Construcción y mantenimiento de accesos** | 2023-03-08 → 2023-03-10 (+2d) | 2024-09-22 → 2024-09-28 (+6d) |  |  |  |
| A1170 | Excavación en Material Común | 2023-03-08 → 2023-03-10 (+2d) | 2023-06-20 → 2023-07-04 (+14d) | 86d → 95d |  | Desbroce y Remoción de Suelo Vegetal con Equipo SS → A1130 SS+3d |
| A1180 | Excavación en roca fracturada | 2023-03-08 → 2023-03-10 (+2d) | 2023-06-20 → 2023-07-04 (+14d) | 86d → 95d |  |  |
| A1190 | Excavación en roca fija con martillo hidráulico | 2023-03-11 → 2023-03-14 (+3d) | 2023-06-23 → 2023-09-06 (+75d) | 86d → 144d |  |  |
| A1200 | Relleno compactado con equipo pesado para accesos | 2023-03-15 → 2023-03-17 (+2d) | 2023-06-25 → 2023-09-09 (+76d) | 85d → 144d | 380d → 0d |  |
| A1210 | Proceso y selección de material propio | 2023-03-15 → 2023-03-17 (+2d) | 2023-06-25 → 2023-09-09 (+76d) | 85d → 144d | 380d → 0d |  |
| A1230 | Mantenimiento de accesos (L = 2km) | 2023-03-15 → 2023-03-17 (+2d) | 2024-09-22 → 2024-09-28 (+6d) | 460d → 463d | 5d → 1d |  |
| 4 | **Construcción de Campamentos** | 2023-03-08 → 2023-03-11 (+3d) | 2024-09-24 → 2024-09-28 (+4d) |  |  |  |
| A1280 | Construcción e Implementación de Polvorin | 2023-03-08 → 2023-03-11 (+3d) | 2023-06-10 → 2023-04-13 (-58d) | 78d → 26d | 393d → 0d | A1070, A1080, A1090, A1100 → A1130 SS+3d, A1070, A1080, A1090, A1100 |
| A1240 | Conformación de terraplén para campamentos | 2023-03-11 → 2023-03-14 (+3d) | 2023-04-13 → 2023-05-14 (+31d) | 26d → 50d | 4d → 1d |  |
| A1250 | Construcción de campamentos | 2023-03-15 → 2023-03-17 (+2d) | 2023-04-16 → 2023-05-18 (+32d) | 26d → 50d | 4d → 1d |  |
| A1260 | Mantenimiento de campamento | 2023-04-17 → 2023-04-19 (+2d) | 2024-09-24 → 2024-09-28 (+4d) | 435d → 437d | 4d → 1d | A1250 → A1250 SS+26d |
| 5 | **Conformación de plataforma para zonas de acopio** | 2023-04-04 → 2023-03-10 (-25d) | 2023-11-25 → 2023-12-19 (+24d) |  |  |  |
| A1300 | Excavación en Material Común | 2023-04-04 → 2023-03-10 (-25d) | 2023-07-13 → 2023-06-20 (-23d) | 82d → 84d | 254d → 0d | Desbroce y remoción de suelo vegetal con equipo SS → A1170 SS |
| A1310 | Relleno compactado con equipo pesado para plataforma de acopio | 2023-04-20 → 2023-03-24 (-27d) | 2023-11-11 → 2023-12-03 (+22d) | 170d → 210d | 254d → 0d |  |
| A1320 | Suministro, construcción e instalación de Cerco perímetrico | 2023-05-05 → 2023-04-10 (-25d) | 2023-11-25 → 2023-12-19 (+24d) | 170d → 210d | 254d → 236d |  |
| A1330 | Suministro, construcción e instalación de garita de control de ingreso y salida | 2023-05-05 → 2023-04-10 (-25d) | 2023-11-25 → 2023-12-19 (+24d) | 170d → 210d | 254d → 236d |  |
| 6 | **Seguridad y Medio Ambiente** | 2023-03-01 → 2023-03-03 (+2d) | 2024-09-28 → 2024-09-29 (+1d) |  |  |  |
| A1340 | Señalización de obra | 2023-03-01 → 2023-03-03 (+2d) | 2024-09-27 → 2024-09-29 (+2d) |  | 1d → 0d |  |
| A1350 | Implementación de controles ambientales durante la construcción | 2023-03-01 → 2023-03-03 (+2d) | 2024-09-27 → 2024-09-29 (+2d) |  | 1d → 0d |  |
| A1360 | Conformación de Material Excedente en DME y DMO | 2023-03-01 → 2023-03-03 (+2d) | 2024-09-27 → 2024-09-29 (+2d) |  | 1d → 0d |  |
| 4 | **EXPLOTACIÓN DE CANTERA** | 2023-03-18 → 2023-03-21 (+3d) | 2024-09-27 → 2024-09-29 (+2d) |  |  |  |
| 1 | **Habilitación de Cantera** | 2023-03-18 → 2023-03-21 (+3d) | 2023-11-11 → 2024-06-29 (+231d) |  |  |  |
| A1390 | Excavación en material común (hasta roca fracturada) | 2023-03-18 → 2023-03-21 (+3d) | 2023-09-05 → 2023-11-30 (+86d) | 139d → 210d |  | Desbroce y remoción de suelo vegetal con equipo SS → A1200 SS+3d |
| A1400 | Excavación en roca fracturada (hasta roca macizo rocoso) | 2023-03-18 → 2023-03-21 (+3d) | 2023-09-05 → 2023-11-30 (+86d) | 139d → 210d |  |  |
| A1410 | Perforación manual y voladura (habilitación de área de perforación para Rockdrill) | 2023-03-25 → 2023-03-29 (+4d) | 2023-11-11 → 2024-06-29 (+231d) | 190d → 379d |  | A1400 SS+6d, Alquiler de Polvorín temporal SS+15d → A1400 SS+7d, A1280 SS+15d |
| 2 | **Producción Material en cantera de cerro (macizo rocoso)** | 2023-04-11 → 2023-04-14 (+3d) | 2024-09-27 → 2024-09-29 (+2d) |  |  |  |
| 1 | **Producción - roca de 0.80 - 1.50 m** | 2023-04-11 → 2023-04-14 (+3d) | 2024-09-27 → 2024-09-29 (+2d) |  |  |  |
| A1420 | Nuevo Alto Perú | 2023-04-11 → 2023-04-14 (+3d) | 2024-09-25 → 2024-09-28 (+3d) |  |  | A1410 SS+12d → A1410 SS+12d, A1310 SS+16d |
| A1430 | San Bartolo 01 | 2023-04-18 → 2023-04-21 (+3d) | 2024-09-26 → 2024-09-29 (+3d) |  |  |  |
| A1460 | Oso 02 | 2023-05-03 → 2023-05-06 (+3d) | 2024-09-27 → 2024-09-29 (+2d) | 425d → 424d |  |  |
| 2 | **Fracturación - roca para gaviones de 0.15 - 0.20 m** | 2023-04-11 → 2023-04-14 (+3d) | 2024-01-30 → 2024-09-29 (+243d) |  |  |  |
| A1480 | Nuevo Alto Perú | 2023-04-11 → 2023-04-14 (+3d) | 2024-01-20 → 2024-09-28 (+252d) | 235d → 441d | 209d → 0d |  |
| A1490 | San Bartolo 01 | 2023-04-18 → 2023-04-21 (+3d) | 2024-01-27 → 2024-09-29 (+246d) | 235d → 436d | 203d → 0d | A1430 SS → A1430 SS, A1480 SS+6d |
| A1520 | Oso 02 | 2023-05-03 → 2023-05-06 (+3d) | 2024-01-30 → 2024-09-29 (+243d) | 225d → 424d | 201d → 0d |  |
| 3 | **Carguio de Material Remanente en acopio para Eliminación** | 2023-04-11 → 2023-04-14 (+3d) | 2024-09-27 → 2024-09-29 (+2d) |  |  |  |
| A1540 | Carguio de Material Remanente en acopio para Eliminación | 2023-04-11 → 2023-04-14 (+3d) | 2024-09-27 → 2024-09-29 (+2d) | 443d → 442d | 1d → 0d |  |
| 3 | **Producción Material en cantera de cauce (boloneria suelta)** | 2023-04-11 → 2023-05-24 (+43d) | 2024-08-21 → 2024-09-07 (+17d) |  |  |  |
| A1550 | Fracturación y selección de Roca con martillo hidráulico | 2023-04-11 → 2023-05-24 (+43d) | 2024-08-21 → 2024-09-07 (+17d) | 412d → 390d | 31d → 19d | A1420 SS → A1400 SS+52d |
| A1560 | Carguio de Material Remanente en acopio para Eliminación | 2023-04-11 → 2023-05-24 (+43d) | 2024-08-21 → 2024-09-07 (+17d) | 412d → 390d | 32d → 19d |  |
| 4 | **Carguio de Material acopiado** | 2023-04-11 → 2023-04-14 (+3d) | 2024-09-27 → 2024-09-29 (+2d) |  |  |  |
| A1570 | Carguio de Material acopiado | 2023-04-11 → 2023-04-14 (+3d) | 2024-09-27 → 2024-09-29 (+2d) | 443d → 442d | 1d → 0d |  |
| 5 | **IMPLEMENTACION PARA CONTROL Y PESAJE DE ROCA** | 2023-03-18 → 2023-03-21 (+3d) | 2024-09-03 → 2024-09-29 (+26d) |  |  |  |
| 1 | **Instalación de Sistema de Pesaje** | 2023-03-18 → 2023-03-21 (+3d) | 2024-09-03 → 2024-09-29 (+26d) |  |  |  |
| A1575 | Obras Civiles | 2023-03-18 → 2023-03-21 (+3d) | 2023-04-20 → 2023-04-22 (+2d) |  | 22d → 0d |  |
| A1580 | Instalación de balanza, caseta y tablero de control de Pesaje | 2023-04-11 → 2023-04-13 (+2d) | 2023-05-12 → 2023-05-14 (+2d) |  | 22d → 0d | A1130, A1575 SS+18d → A1575 SS+18d |
| A1590 | Operación y control de Sistema de pesaje | 2023-04-18 → 2023-04-20 (+2d) | 2024-09-03 → 2024-09-29 (+26d) | 416d → 437d | 22d → 0d |  |
| 6 | **PRUEBAS DE CONTROL DE CALIDAD** | 2023-04-11 → 2023-04-14 (+3d) | 2024-09-27 → 2024-09-29 (+2d) |  |  |  |
| A1600 | Ensayos de Roca | 2023-04-11 → 2023-04-14 (+3d) | 2024-09-27 → 2024-09-29 (+2d) | 443d → 442d | 1d → 0d |  |
